# PTC07004a-RiserInspector

Schedule from MS Project, 2007-09-03 to 2008-06-16, costs in R$.
Estudante

## Calendars

- Standard: Mon-Fri 08:00-12:00, 13:00-17:00; Sat-Sun off.

## Resources

| Resource | Rate |
| --- | --- |
| Eletricista e software | 35.15 |
| Controle e automação | 35.15 |
| Projeto Mecânico | 83.25 |
| estagiários | 5.5 |

## Schedule

| ID | WBS | Task | Type | Duration | Start | Finish | Predecessors | Baseline start | Baseline finish | Baseline duration | Total slack | Resources | Work | Cost | Baseline cost |
| --- | --- | --- | --- | --- | --- | --- | --- | --- | --- | --- | --- | --- | --- | --- | --- |
| 1 | 1 | **Projeto Trator de PIG** |  | 206d | 2007-09-03 | 2008-06-16 |  | 2007-10-01 | 2008-05-15 | 164d | 0d |  | 5519.2h | 174,249.92 | 175,495.12 |
| 2 | 1.1 | **Projeto conceitual** |  | 29d | 2007-09-03 | 2007-10-11 |  | 2007-10-01 | 2007-11-06 | 27d | 0d |  | 370.4h | 24,371.16 | 25,037.16 |
| 3 | 1.1.1 | Levantamento de requisitos |  | 2d | 2007-09-03 | 2007-09-04 |  | 2007-10-01 | 2007-10-02 | 2d | 0d | Controle e automação [70%]; Eletricista e software [70%]; Projeto Mecânico [50%] | 30.4h | 1,453.36 | 2,119.36 |
| 4 | 1.1.2 | **Concepção mecânica** |  | 25d | 2007-09-05 | 2007-10-09 | 3 | 2007-10-03 | 2007-11-06 | 25d | 0d |  | 228h | 18,981 | 18,981 |
| 5 | 1.1.2.1 | Sistema de tracionamento |  | 2w | 2007-09-05 | 2007-09-18 |  | 2007-10-03 | 2007-10-16 | 2w | 0d | Projeto Mecânico [120%] | 96h | 7,992 | 7,992 |
| 6 | 1.1.2.2 | Braço com garra |  | 2w | 2007-09-19 | 2007-10-02 | 5 | 2007-10-24 | 2007-11-06 | 2w | 0d | Projeto Mecânico [120%] | 96h | 7,992 | 7,992 |
| 7 | 1.1.2.3 | Chassi |  | 1w | 2007-10-03 | 2007-10-09 | 6 | 2007-10-17 | 2007-10-23 | 1w | 0d | Projeto Mecânico [90%] | 36h | 2,997 | 2,997 |
| 8 | 1.1.3 | **Arquitetura de controle** |  | 10d | 2007-09-26 | 2007-10-09 | 3 | 2007-10-03 | 2007-10-09 | 5d | 0d |  | 112h | 3,936.8 | 3,936.8 |
| 9 | 1.1.3.1 | Arquitetura de hardware de controle |  | 1w | 2007-09-26 | 2007-10-02 | 6FF | 2007-10-03 | 2007-10-09 | 1w | 0d | Controle e automação [70%]; Eletricista e software [70%] | 56h | 1,968.4 | 1,968.4 |
| 10 | 1.1.3.2 | Arquitetura do software de controle |  | 1w | 2007-10-03 | 2007-10-09 | 9 | 2007-10-03 | 2007-10-09 | 1w | 0d | Controle e automação [70%]; Eletricista e software [70%] | 56h | 1,968.4 | 1,968.4 |
| 11 | 1.1.4 | Projeto básico ( MC1) | milestone | 0w | 2007-10-11 | 2007-10-11 | 66 |  |  |  | 0d |  |  |  |  |
| 12 | 1.2 | **Veiculo Trator de PIG** |  | 177d | 2007-10-12 | 2008-06-16 | 2 | 2007-11-07 | 2008-05-15 | 137d | 0d |  | 2408h | 91,824.2 | 88,607.2 |
| 13 | 1.2.1 | **Projeto detalhado** |  | 177d | 2007-10-12 | 2008-06-16 | 8 | 2007-11-07 | 2008-05-15 | 137d | 0d |  | 1820h | 70,863.2 | 67,646.2 |
| 14 | 1.2.1.1 | Projeto dos mecanismos de tracionamento |  | 3w | 2007-10-16 | 2007-11-05 | 35SS | 2007-11-07 | 2007-11-27 | 3w | 3d | Controle e automação [10%]; Projeto Mecânico [80%]; estagiários [50%] | 168h | 8,743.8 | 8,743.8 |
| 15 | 1.2.1.2 | Projeto do braço e garra |  | 4w | 2007-10-12 | 2007-11-08 |  | 2007-11-07 | 2007-12-04 | 4w | 0d | Controle e automação [10%]; Projeto Mecânico [80%]; estagiários [50%] | 224h | 11,658.4 | 11,658.4 |
| 16 | 1.2.1.3 | Modelamento do PIG |  | 1w | 2007-11-09 | 2007-11-15 | 14, 15 | 2007-12-05 | 2007-12-11 | 1w | 0d | Projeto Mecânico [90%]; estagiários | 76h | 3,217 | 3,217 |
| 17 | 1.2.1.4 | Integração de câmeras e iluminação |  | 1w | 2007-11-16 | 2007-11-22 | 16 | 2007-11-07 | 2007-11-13 | 1w | 5d | Projeto Mecânico [90%]; estagiários | 76h | 3,217 | 3,217 |
| 18 | 1.2.1.5 | Modelamento cinemático |  | 1w | 2007-11-16 | 2007-11-22 | 16, 14FF | 2007-12-12 | 2007-12-18 | 1w | 0d | Projeto Mecânico [90%]; estagiários | 76h | 3,217 | 3,217 |
| 19 | 1.2.1.6 | Projeto de vedações e passages |  | 1w | 2007-11-23 | 2007-11-29 | 18 |  |  |  | 0d | Projeto Mecânico [90%]; estagiários | 76h | 3,217 |  |
| 20 | 1.2.1.7 | Definição de componentes padronizados |  | 1w | 2007-11-30 | 2007-12-06 | 16FF+1w, 17, 19, 18 | 2007-12-12 | 2007-12-18 | 1w | 0d | Projeto Mecânico [90%]; estagiários | 76h | 3,217 | 3,217 |
| 21 | 1.2.1.8 | Revisão do modelo |  | 1w | 2007-12-07 | 2007-12-13 | 38, 20 | 2007-11-09 | 2007-11-15 | 1w | 0d | estagiários; Projeto Mecânico [120%] | 88h | 4,216 | 4,216 |
| 22 | 1.2.1.9 | Detalhamento dos componentes |  | 4w | 2007-12-14 | 2008-01-10 | 21 | 2007-11-16 | 2007-12-13 | 4w | 0d | estagiários [200%]; Projeto Mecânico | 480h | 15,080 | 15,080 |
| 23 | 1.2.1.10 | Projeto pronto para construção (MC3) | milestone | 0w | 2008-01-14 | 2008-01-14 | 67 | 2007-12-13 | 2007-12-13 | 0w | 0d |  |  |  |  |
| 24 | 1.2.1.11 | Revisão de projeto do veículo |  | 4w | 2008-05-20 | 2008-06-16 | 23, 64 | 2008-04-18 | 2008-05-15 | 4w | 0d | Projeto Mecânico; estagiários [200%] | 480h | 15,080 | 15,080 |

| ID | WBS | Task | Type | Duration | Start | Finish | Predecessors | Baseline start | Baseline finish | Baseline duration | Total slack | Free slack | Resources | Work | Cost | Baseline cost |
| --- | --- | --- | --- | --- | --- | --- | --- | --- | --- | --- | --- | --- | --- | --- | --- | --- |
| 25 | 1.2.2 | **Construção** |  | 75d | 2008-01-08 | 2008-04-21 |  | 2007-12-07 | 2008-03-20 | 75d | 5d |  |  | 588h | 20,961 | 20,961 |
| 26 | 1.2.2.1 | Levantamento de fornecedores |  | 1w | 2008-01-08 | 2008-01-15 | 27SF | 2007-12-07 | 2007-12-14 | 1w | 110d |  | Projeto Mecânico [50%]; estagiários | 60h | 1,885 | 1,885 |
| 27 | 1.2.2.2 | Orçamentação |  | 2w | 2008-01-15 | 2008-01-28 | 23 | 2007-12-14 | 2007-12-27 | 2w | 0d |  | Projeto Mecânico [50%]; estagiários | 120h | 3,770 | 3,770 |
| 28 | 1.2.2.3 | Acompanhamento da fabricação |  | 8w | 2008-01-29 | 2008-03-24 | 27 | 2007-12-28 | 2008-02-21 | 8w | 0d |  | Projeto Mecânico [10%] | 32h | 2,664 | 2,664 |
| 29 | 1.2.2.4 | Recepção de componentes |  | 2w | 2008-03-25 | 2008-04-07 | 28 | 2008-02-22 | 2008-03-06 | 2w | 0d |  | Projeto Mecânico [70%]; estagiários | 136h | 5,102 | 5,102 |
| 30 | 1.2.2.5 | Montagem mecânica |  | 2w | 2008-04-08 | 2008-04-21 | 29 | 2008-03-07 | 2008-03-20 | 2w | 0d |  | estagiários [200%]; Projeto Mecânico | 240h | 7,540 | 7,540 |
| 31 | 1.3 | **Sistema de controle** |  | 176.89d | 2007-10-10 | 2008-06-12 |  | 2007-10-10 | 2008-05-08 | 152d | 2.11d |  |  | 2072h | 42,706.4 | 43,372.4 |
| 32 | 1.3.1 | **Projeto elétrico** |  | 34d | 2007-10-10 | 2007-11-26 | 8 | 2007-10-10 | 2007-11-22 | 32d | 3d |  |  | 376h | 7,998 | 7,998 |
| 33 | 1.3.1.1 | Especificação do sistema de controle |  | 2d | 2007-10-10 | 2007-10-11 |  | 2007-10-10 | 2007-10-11 | 2d | 3d | 0d | Controle e automação [50%]; Eletricista e software [50%] | 16h | 562.4 | 562.4 |
| 34 | 1.3.1.2 | Definição das interfaces |  | 2d | 2007-10-12 | 2007-10-15 | 33 | 2007-10-12 | 2007-10-15 | 2d | 3d | 0d | Controle e automação [50%]; Eletricista e software [50%] | 16h | 562.4 | 562.4 |
| 35 | 1.3.1.3 | Projeto da lógica de controle elétrico |  | 1w | 2007-10-16 | 2007-10-22 | 34 | 2007-10-16 | 2007-10-22 | 1w | 3d | 0d | Controle e automação [50%]; Eletricista e software [50%] | 40h | 1,406 | 1,406 |
| 36 | 1.3.1.4 | Projeto da fonte |  | 1w | 2007-10-23 | 2007-10-29 | 35 | 2007-10-23 | 2007-10-29 | 1w | 20d | 0d | Eletricista e software [50%]; estagiários | 60h | 923 | 923 |
| 37 | 1.3.1.5 | Especificação de cabos e conectores |  | 3d | 2007-10-30 | 2007-11-01 | 36 | 2007-10-30 | 2007-11-01 | 3d | 20d | 0d | Eletricista e software; estagiários | 48h | 975.6 | 975.6 |
| 38 | 1.3.1.6 | Modelamento do cabeamento |  | 1w | 2007-11-02 | 2007-11-08 | 37 | 2007-11-02 | 2007-11-08 | 1w | 20d | 0d | Eletricista e software [80%]; estagiários | 72h | 1,344.8 | 1,344.8 |
| 39 | 1.3.1.7 | Detalhamento de chicotes |  | 1w | 2007-11-09 | 2007-11-15 | 38 | 2007-11-09 | 2007-11-15 | 1w | 107d | 0d | Eletricista e software [80%]; estagiários [80%] | 64h | 1,300.8 | 1,300.8 |
| 40 | 1.3.1.8 | Especificação de componentes de fontes e cabos |  | 1w | 2007-11-16 | 2007-11-22 | 39 | 2007-11-16 | 2007-11-22 | 1w | 145d | 0d | Eletricista e software [50%]; estagiários | 60h | 923 | 923 |
| 41 | 1.3.1.9 | Projeto elétrico concluído (MC2) | milestone | 0w | 2007-11-26 | 2007-11-26 | 68 |  |  |  | 145d |  |  |  |  |  |
| 42 | 1.3.2 | **Construção** |  | 70d | 2007-10-12 | 2008-01-17 |  | 2007-10-12 | 2008-01-17 | 70d | 75d |  |  | 656h | 13,570.4 | 14,236.4 |
| 43 | 1.3.2.1 | Aquisição dos sistemas |  | 8w | 2007-10-12 | 2007-12-06 | 33 | 2007-10-12 | 2007-12-06 | 8w | 75d | 0d | Eletricista e software [10%] | 32h | 1,124.8 | 1,124.8 |
| 44 | 1.3.2.2 | Aquisição de componentes |  | 2w | 2007-11-02 | 2007-11-15 | 36, 37 | 2007-11-02 | 2007-11-15 | 2w | 92d | 0d | Eletricista e software [20%] | 16h | 562.4 | 562.4 |
| 45 | 1.3.2.3 | Fabricação de PCI |  | 2w | 2007-11-16 | 2007-11-29 | 44 | 2007-11-16 | 2007-11-29 | 2w | 92d | 0d | Eletricista e software [10%] | 8h | 281.2 | 281.2 |
| 46 | 1.3.2.4 | Montagem da fonte |  | 1w | 2007-11-30 | 2007-12-06 | 45 | 2007-11-30 | 2007-12-06 | 1w | 92d | 0d | Eletricista e software [50%]; estagiários | 60h | 923 | 923 |
| 47 | 1.3.2.5 | Pré-montagem de chicotes |  | 1w | 2007-12-07 | 2007-12-13 | 39, 46 | 2007-12-07 | 2007-12-13 | 1w | 92d |  | estagiários; Eletricista e software [50%] | 60h | 923 | 1,589 |
| 48 | 1.3.2.6 | Configuração do controlador |  | 2w | 2007-12-07 | 2007-12-20 | 43 | 2007-12-07 | 2007-12-20 | 2w | 75d | 0d | Controle e automação [75%]; Eletricista e software [25%]; estagiários | 160h | 3,252 | 3,252 |
| 49 | 1.3.2.7 | Montagem em bancada dos sistemas |  | 4w | 2007-12-21 | 2008-01-17 | 48 | 2007-12-21 | 2008-01-17 | 4w | 75d | 0d | Controle e automação [50%]; Eletricista e software [50%]; estagiários | 320h | 6,504 | 6,504 |

| ID | WBS | Task | Type | Duration | Start | Finish | Predecessors | Baseline start | Baseline finish | Baseline duration | Total slack | Free slack | Resources | Work | Cost | Baseline cost |
| --- | --- | --- | --- | --- | --- | --- | --- | --- | --- | --- | --- | --- | --- | --- | --- | --- |
| 50 | 1.3.3 | **Desenvolvimento do software** |  | 104.89d | 2008-01-18 | 2008-06-12 |  | 2008-01-18 | 2008-05-08 | 80d | 0.11d | 0d |  | 1040h | 21,138 | 21,138 |
| 51 | 1.3.3.1 | **Software Emabarcado** |  | 102d | 2008-01-18 | 2008-06-09 |  | 2008-01-18 | 2008-05-08 | 80d | 3d |  |  | 800h | 16,260 | 16,260 |
| 52 | 1.3.3.1.1 | Módulo de controle |  | 4w | 2008-01-18 | 2008-02-14 | 49 | 2008-01-18 | 2008-02-14 | 4w | 75d | 0d | Controle e automação [90%]; estagiários; Eletricista e software [10%] | 320h | 6,504 | 6,504 |
| 53 | 1.3.3.1.2 | Revisão do software embarcado |  | 3w | 2008-05-20 | 2008-06-09 | 64 | 2008-04-18 | 2008-05-08 | 3w | 3d |  | Eletricista e software; estagiários [200%]; Controle e automação | 480h | 9,756 | 9,756 |
| 54 | 1.3.3.2 | **Software gerenciador do sistema** |  | 84.89d | 2008-02-15 | 2008-06-12 |  | 2008-02-15 | 2008-04-24 | 50d | 0.11d |  |  | 240h | 4,878 | 4,878 |
| 55 | 1.3.3.2.1 | Interface com o usuário para guiagem de missão |  | 2w | 2008-02-15 | 2008-02-28 | 52 | 2008-02-15 | 2008-02-28 | 2w | 75d |  | Controle e automação [90%]; estagiários; Eletricista e software [10%] | 160h | 3,252 | 3,252 |
| 56 | 1.3.3.2.2 | Revisão do software gerenciador do sistema |  | 1w | 2008-06-05 | 2008-06-12 | 64 | 2008-04-18 | 2008-04-24 | 1w | 0.11d |  | Controle e automação [90%]; estagiários; Eletricista e software [10%] | 80h | 1,626 | 1,626 |
| 57 | 1.4 | **Integração** |  | 10d | 2008-04-22 | 2008-05-05 | 30 | 2008-03-21 | 2008-04-03 | 10d | 0d |  |  | 388h | 6,714.6 | 8,046.6 |
| 58 | 1.4.1 | Instalação de sistemas de imagem e instr. |  | 1w | 2008-04-22 | 2008-04-28 | 45, 43 | 2008-03-21 | 2008-03-27 | 1w | 35d |  | Eletricista e software [50%]; Controle e automação [50%]; estagiários [200%] | 120h | 1,846 | 1,846 |
| 59 | 1.4.2 | Passagem de cabos |  | 1w | 2008-04-22 | 2008-04-28 | 47 | 2008-03-21 | 2008-03-27 | 1w | 0d |  | Controle e automação [10%]; Eletricista e software [50%]; estagiários [200%] | 104h | 1,283.6 | 1,283.6 |
| 60 | 1.4.3 | Ligação do sistema |  | 1w | 2008-04-29 | 2008-05-05 | 59, 48 | 2008-03-28 | 2008-04-03 | 1w | 0d |  | Controle e automação; Eletricista e software; estagiários [200%]; Projeto Mecânico [10%] | 164h | 3,585 | 4,917 |
| 61 | 1.4.4 | Protótipo Pronto para testes (MC4) | milestone | 0w | 2008-05-05 | 2008-05-05 | 60 |  |  |  | 0d |  |  |  |  |  |
| 62 | 1.5 | **Testes** |  | 10d | 2008-05-06 | 2008-05-19 |  | 2008-04-04 | 2008-04-17 | 10d | 0d |  |  | 148h | 4,401 | 6,066 |
| 63 | 1.5.1 | Bancada |  | 1w | 2008-05-06 | 2008-05-12 | 61 | 2008-04-04 | 2008-04-10 | 1w | 0d |  | Controle e automação [75%]; Eletricista e software [75%]; estagiários; Projeto Mecânico [20%] | 108h | 2,995 | 3,994 |
| 64 | 1.5.2 | Teste de campo |  | 1w | 2008-05-12 | 2008-05-19 | 63 | 2008-04-10 | 2008-04-17 | 1w | 0d |  | Projeto Mecânico; estagiários; Controle e automação | 40h | 1,406 | 2,072 |
| 65 | 1.6 | **Documentação** |  | 178.89d | 2007-10-10 | 2008-06-16 |  | 2007-11-07 | 2008-05-12 | 134d | 0d |  |  | 132.8h | 4,232.56 | 4,365.76 |
| 66 | 1.6.1 | Concepção |  | 2d | 2007-10-10 | 2007-10-11 | 7, 10 | 2007-11-07 | 2007-11-08 | 2d | 0d |  | Controle e automação [10%]; Eletricista e software [10%]; estagiários; Projeto Mecânico | 35.2h | 1,532.48 | 1,532.48 |
| 67 | 1.6.2 | Projeto mecânico |  | 2d | 2008-01-11 | 2008-01-14 | 22 | 2007-12-14 | 2007-12-17 | 2d | 0d |  | Controle e automação [10%]; Eletricista e software [10%]; estagiários; Projeto Mecânico [90%] | 33.6h | 1,399.28 | 1,532.48 |
| 68 | 1.6.3 | Projeto Elétrico |  | 2d | 2007-11-23 | 2007-11-26 | 40 | 2007-11-23 | 2007-11-26 | 2d | 145d | 0d | Controle e automação [10%]; Eletricista e software [90%]; estagiários | 32h | 650.4 | 650.4 |
| 69 | 1.6.4 | Software |  | 2d | 2008-06-12 | 2008-06-16 | 50 | 2008-05-09 | 2008-05-12 | 2d | 0.11d |  | Controle e automação [90%]; Eletricista e software [10%]; estagiários | 32h | 650.4 | 650.4 |
| 70 | 1.7 | Entrega do Projeto (MC5) | milestone | 0d | 2008-06-16 | 2008-06-16 | 65 | 2008-05-12 | 2008-05-12 | 0d | 0.11d |  |  |  |  |  |
